# Harmonogram_VD_Orlik_final

Schedule from MS Project, 2020-10-01 to 2025-12-19.
Poyry Environment a.s.

## Calendars

- Standardní: Mon-Fri 09:00-13:00, 14:00-18:00; Sat-Sun off.

## Schedule

| ID | WBS | Task | Type | Duration | Start | Finish | Predecessors | Total slack | Free slack | Deadline | ZÁVAZNÝ TERMÍN |
| --- | --- | --- | --- | --- | --- | --- | --- | --- | --- | --- | --- |
| 1 | 1 | Nabytí účinnosti smlouvy o dílo | milestone, manual | 0d | 2020-10-01 | 2020-10-01 |  |  |  |  |  |
| 2 | 2 | Koordinace účastníků stavby |  | 1mo | 2020-10-01 | 2020-10-28 | 1 | 122d | 0d |  |  |
| 3 | 3 | Předání staveniště | milestone, manual | 0d | 2020-12-30 | 2020-12-30 | 2FS+1mo |  |  |  |  |
| 4 | 4 | **Manipulace s hladinami - ZÁVAZNÉ TERMÍNY** |  | 847d | 2020-12-01 | 2024-02-29 |  | 0d |  |  |  |
| 5 | 4.1 | Snížení hladiny ve VD Orlík na 339,00 m n. m. | milestone, manual | 0d | 2021-09-01 | 2021-09-01 |  |  |  |  | FIXNÍ TERMÍN |
| 6 | 4.2 | Zvýšení hladiny ve VD Orlík min na 347,60 m n. m. | milestone, manual | 0d | 2022-03-31 | 2022-03-31 |  |  |  |  | FIXNÍ TERMÍN |
| 7 | 4.3 | Konec snížení hladiny ve VD Orlík | milestone, manual | 0d | 2022-11-30 | 2022-11-30 |  |  |  |  | FIXNÍ TERMÍN |
| 8 | 4.4 | Snížení hladiny ve VD Orlík na 343,00 m n. m. | milestone, manual | 0d | 2023-10-01 | 2023-10-01 |  |  |  |  | FIXNÍ TERMÍN |
| 9 | 4.5 | Konec snížení hladiny ve VD Orlík | milestone, manual | 0d | 2024-02-29 | 2024-02-29 |  |  |  |  | FIXNÍ TERMÍN |
| 10 | 4.6 | Snížení hladiny VD Kamýk na max 284,60 m n. m. | milestone, manual | 0d | 2020-12-01 | 2020-12-01 |  |  |  |  |  |
| 11 | 4.7 | Konec snížení hladiny ve VD Kamýk | milestone, manual | 0d | 2023-03-30 | 2023-03-30 |  |  |  |  |  |
| 12 | 4.8 | Snížení hladiny ve VD Kamýk na max 282,60 m n. m. | milestone, manual | 0d | 2023-08-15 | 2023-08-15 | 11 |  |  |  |  |
| 13 | 4.9 | Konec snížení hladiny ve VD Kamýk | milestone, manual | 0d | 2023-11-30 | 2023-11-30 |  |  |  |  |  |
| 14 | 5 | Uzavření silnice III/0046 - ZÁVAZNÝ TERMÍN | milestone, manual | 0d | 2023-04-01 | 2023-04-01 | 22, 24 |  |  |  |  |
| 15 | 6 | Konec uzávěrky silnice III/0046 - ZÁVAZNÝ TERMÍN | milestone, manual | 0d | 2024-11-25 | 2024-11-25 | 174FS+1w |  |  | 2024-11-30 |  |
| 16 | 7 | **Správní úkony před zahájením realizace stavby** |  | 80d | 2020-10-29 | 2021-02-17 | 2 | 148d | 0d |  |  |
| 17 | 7.1 | Povolení zařízení staveniště včetně projednání |  | 1mo | 2021-01-21 | 2021-02-17 | 20 | 148d | 0d |  | Správní úkony před zahájením realizace stavby |
| 18 | 7.2 | Bilogické hodnocení |  | 1mo | 2020-10-29 | 2020-11-25 | 2 | 188d | 0d |  | Správní úkony před zahájením realizace stavby |
| 19 | 7.3 | Povolení výjimky z ochrany ZCHD živočichů |  | 1mo | 2020-11-26 | 2020-12-23 | 18 | 188d |  |  | Správní úkony před zahájením realizace stavby |
| 20 | 7.4 | EIA |  | 3mo | 2020-10-29 | 2021-01-20 | 2 | 148d | 0d |  | Správní úkony před zahájením realizace stavby |
| 21 | 7.5 | Povolení DIO |  | 1mo | 2020-10-29 | 2020-11-25 | 2 | 188d | 0d |  | Správní úkony před zahájením realizace stavby |
| 22 | 7.6 | Povolení uzavírky komunikace |  | 1mo | 2020-11-26 | 2020-12-23 | 21 | 188d |  |  | Správní úkony před zahájením realizace stavby |
| 23 | 7.7 | Povolení zvláštního užívání komunikace |  | 1mo | 2020-11-26 | 2020-12-23 | 21 | 188d | 40d |  | Správní úkony před zahájením realizace stavby |
| 24 | 7.8 | Stanovení přechodného dopravního značení |  | 1mo | 2020-11-26 | 2020-12-23 | 21 | 188d | 40d |  | Správní úkony před zahájením realizace stavby |
| 25 | 7.9 | Povolení trhacích prací |  | 2mo | 2020-10-29 | 2020-12-23 | 2 | 188d |  |  | Správní úkony před zahájením realizace stavby |

Notes:
- 5: FIXNÍ TERMÍN bez možnosti změny délky a termínu
- 6: FIXNÍ TERMÍN bez možnosti změny délky a termínu
- 7: FIXNÍ TERMÍN bez možnosti změny délky a termínu
- 8: FIXNÍ TERMÍN bez možnosti změny délky a termínu
- 9: FIXNÍ TERMÍN bez možnosti změny délky a termínu
- 10: Maximální termín v němž bude možno udržovat hladinu v předepsaném režimu dle předchozí dohody s investorem a dle hydrologické situace.
- 11: Maximální termín v němž bude možno udržovat hladinu v předepsaném režimu dle předchozí dohody s investorem a dle hydrologické situace.
- 12: Fixní doba trvání snížení hladiny, změna termínu snížení je možná dle potřeby zhotovitele pro realizaci SO 04.
- 13: Fixní doba trvání snížení hladiny, změna termínu snížení je možná dle potřeby zhotovitele pro realizaci SO 04.

| ID | WBS | Task | Duration | Start | Finish | Predecessors | Total slack | Free slack | Constraint | ZÁVAZNÝ TERMÍN |
| --- | --- | --- | --- | --- | --- | --- | --- | --- | --- | --- |
| 26 | 8 | **Zařízení staveniště** | 1278d | 2020-12-30 | 2025-11-21 | 3 | 20d |  |  |  |
| 27 | 8.1 | Mobilní betonárny | 1d | 2021-02-18 | 2021-02-18 | 17, 23, 24, 3 | 277d | 175d |  | Zařízení staveniště |
| 28 | 8.2 | Jeřáby | 1d | 2021-02-18 | 2021-02-18 | 17, 3 | 276d | 175d |  | Zařízení staveniště |
| 29 | 8.3 | Záložní zdroj pro betonárny | 1d | 2021-02-18 | 2021-02-18 | 17, 3 | 277d | 175d |  | Zařízení staveniště |
| 30 | 8.4 | Výroba posuvného bednění | 1d | 2020-12-30 | 2020-12-30 | 2 | 847d | 211d |  | Zařízení staveniště |
| 31 | 8.5 | Výroba bednících ramenátů pro přelivnou hranu | 1d | 2020-12-30 | 2020-12-30 | 2 | 333d | 323d |  | Zařízení staveniště |
| 32 | 8.6 | **Buňkoviště** | 1242d | 2021-02-18 | 2025-11-21 | 17, 23, 24, 3 | 20d |  |  | Zařízení staveniště |
| 33 | 8.6.1 | Zřízení buňkoviště | 1d | 2021-02-18 | 2021-02-18 | 17, 23, 24, 3 | 148d | 138d |  |  |
| 34 | 8.6.2 | Zrušení buňkoviště | 1d | 2025-11-21 | 2025-11-21 | 212FF | 20d |  |  |  |
| 35 | 8.7 | Oplocení ploch staveniště, schodiště z koruny hráze | 1d | 2021-02-18 | 2021-02-18 | 17, 3 | 148d | 138d |  | Zařízení staveniště |
| 36 | 8.8 | **Provedení požadavků vyplývajících ze zprávy BOZP** | 1242d | 2021-02-18 | 2025-11-21 | 3 | 20d |  |  | Zařízení staveniště |
| 37 | 8.8.1 | Zahájení provádění | 1d | 2021-02-18 | 2021-02-18 | 3, 17 | 148d | 138d |  |  |
| 38 | 8.8.2 | Ukončení provádění | 1d | 2025-11-21 | 2025-11-21 | 212FF | 20d |  |  |  |
| 39 | 8.9 | Dočasná trafostanice | 1d | 2021-02-18 | 2021-02-18 | 3, 17 | 1261d |  |  | Zařízení staveniště |
| 40 | 8.10 | Zajištění ploch zařízení staveniště nad rámec DPS | 1d | 2020-12-30 | 2020-12-30 | 3, 2 | 1297d |  |  | Zařízení staveniště |
| 41 | 9 | **Výběr a odzkoušení betonové směsi** | 256d | 2020-10-29 | 2021-10-21 | 2 | 122d |  |  |  |
| 42 | 9.1 | Prověření receptur betonové směsi, jejich návrh a výběr | 13w | 2020-10-29 | 2021-01-27 | 2 | 122d | 0d |  |  |
| 43 | 9.2 | Provedení potřebných zkoušek na zkušebních tělesech a korekce návrhu | 66d | 2021-01-28 | 2021-04-29 | 42 | 122d | 0d |  |  |
| 44 | 9.3 | Zkouška mrazuvzdornosti | 4w | 2021-04-30 | 2021-05-27 | 43 | 122d | 0d |  |  |
| 45 | 9.4 | Zkušební blok | 65d | 2021-05-28 | 2021-08-26 | 44, 136SS+2mo, 138 | 122d | 0d |  |  |
| 46 | 9.5 | Zkouška mrazuvzdornosti na zkušebním bloku | 4w | 2021-08-27 | 2021-09-23 | 45 | 122d | 0d |  |  |
| 47 | 9.6 | Rezerva | 4w | 2021-09-24 | 2021-10-21 | 46 | 636d | 0d |  |  |
| 48 | 10 | **SO 01 Vtokový objekt** | 1101d | 2021-09-01 | 2025-11-19 |  | 2d |  |  |  |
| 49 | 10.1 | Zakládání - zajištění stavební jámy, zemní práce | 117d | 2021-09-01 | 2022-03-14 | 5, 16, 35, 183FF+4mo, 6FF-3w, 33, 37 | 10d | 0d |  |  |
| 50 | 10.2 | Betonáž dna včetně přelivné hrany | 30.8w | 2022-03-01 | 2022-09-30 | 27, 28SS+2d, 29, 46, 49FS-10d, 52SS, 31FS-4w | 10d | 0d |  |  |
| 51 | 10.3 | Vztlaková drenáž | 15d | 2022-03-01 | 2022-03-21 | 49FS-10d, 6FF-2w | 959d |  |  |  |
| 52 | 10.4 | Injektáž zajištění stavební jámy | 4w | 2021-11-03 | 2021-11-30 | 49SS+9w | 94d | 0d |  |  |
| 53 | 10.5 | Injektáž dno | 16w | 2022-03-22 | 2022-07-11 | 50SS+15d | 879d |  |  |  |
| 54 | 10.6 | Injektáž zavázání | 5w | 2022-08-30 | 2022-10-03 | 55FF-10w | 40d | 30d |  |  |
| 55 | 10.7 | Betonáž stěn | 195d | 2022-03-15 | 2022-12-12 | 65FS-1w, 50SS+10d | 10d | 0d |  |  |
| 56 | 10.8 | Betonáž stropů | 85d | 2022-08-09 | 2022-12-05 | 55SS+105d | 49d | 0d |  |  |
| 57 | 10.9 | Betonáž stropů - část 2 | 2w | 2025-08-11 | 2025-08-22 | 67, 55, 56 | 15d |  |  |  |
| 58 | 10.10 | Provizorní hrazení | 1d | 2022-11-29 | 2022-11-30 | 55FS-10d, 7FF | 778d |  |  |  |
| 59 | 10.11 | Provizorní hrazení - skládka hradidel | 2w | 2025-06-09 | 2025-06-20 | 130FS+2w | 110d |  | start no earlier than 2024-09-30 |  |
| 60 | 10.12 | Provizorní hrazení - montáž segmenty | 3w | 2023-04-11 | 2023-05-01 | 56FS+90d, 66FS+1w | 614d | 0d |  |  |
| 61 | 10.13 | Strojovny, pláště včetně vnitřního zařízení | 13w | 2023-04-18 | 2023-07-17 | 60FS-2w | 614d |  |  |  |

Notes:
- 27: Doba trvání dle technologického postupu zhotovitele.
- 28: Doba trvání dle technologického postupu zhotovitele.
- 29: Doba trvání dle technologického postupu zhotovitele.
- 30: Doba trvání dle technologického postupu zhotovitele.
- 31: Doba trvání dle technologického postupu zhotovitele.
- 32: Doba trvání dle technologického postupu zhotovitele.
- 33: Doba trvání dle technologického postupu zhotovitele.
- 34: Doba trvání dle technologického postupu zhotovitele.
- 35: Doba trvání dle technologického postupu zhotovitele.
- 39: Doba trvání dle technologického postupu zhotovitele.
- 40: Doba trvání dle technologického postupu zhotovitele.

| ID | WBS | Task | Duration | Start | Finish | Predecessors | Total slack | Free slack | Constraint |
| --- | --- | --- | --- | --- | --- | --- | --- | --- | --- |
| 62 | 10.14 | **Obslužné komunikace v době výstavby** | 1028d | 2021-09-01 | 2025-08-08 |  | 75d |  |  |
| 63 | 10.14.1 | Cesty - část 1 | 2w | 2021-09-01 | 2021-09-14 | 49SS | 1093d |  |  |
| 64 | 10.14.2 | Cesty - část 2 | 2w | 2021-11-24 | 2021-12-07 | 49SS+11w, 52SS+3w | 1033d |  |  |
| 65 | 10.14.3 | Cesty - část 3 | 3w | 2022-03-01 | 2022-03-21 | 49FS-2w | 10d | 0d |  |
| 66 | 10.14.4 | Cesty - část 4 | 4w | 2023-02-27 | 2023-03-24 | 56FS+4w, 70FS-1w, 199, 210, 203 | 10d | 0d |  |
| 67 | 10.14.5 | Cesty - část 5 | 1w | 2025-08-04 | 2025-08-08 | 130FS+2w, 181FS+2w | 0d |  |  |
| 68 | 10.15 | Příjezdová komunikace k provoznímu středisku | 8w | 2025-09-25 | 2025-11-19 | 71, 128FS+4w | 2d | 0d |  |
| 69 | 10.16 | **Zpětné zásypy** | 747d | 2022-11-15 | 2025-09-24 |  | 0d |  |  |
| 70 | 10.16.1 | Část 1 | 7w | 2022-11-15 | 2023-03-03 | 54, 55FS-4w | 10d | 0d |  |
| 71 | 10.16.2 | Část 2 | 5w | 2025-08-11 | 2025-09-24 | 67 | 0d |  |  |
| 72 | 10.17 | Dešťová kanalizace | 4w | 2025-08-25 | 2025-09-19 | 71SS+2w | 0d |  |  |
| 73 | 10.18 | **Opevnění břehu** | 175d | 2023-03-13 | 2023-11-10 |  | 239d |  |  |
| 74 | 10.18.1 | Část 1 ve stavební jímce | 3w | 2023-03-13 | 2023-03-31 | 70FS+1w | 690d |  |  |
| 75 | 10.18.2 | Část 2 mimo jímku | 3w | 2023-10-23 | 2023-11-10 | 8FS+3w | 79d |  | finish no later than 2024-02-29 |
| 76 | 10.19 | Demontáž zajištění jámy | 4w | 2023-11-13 | 2023-12-08 | 8FS+6w | 59d |  | finish no later than 2024-02-29 |
| 77 | 10.20 | **Dokončovací práce, zábradlí, žebříky apod.** | 708d | 2023-03-06 | 2025-11-19 |  | 2d |  |  |
| 78 | 10.20.1 | Část 1 | 5w | 2023-03-06 | 2023-04-07 | 70 | 685d |  |  |
| 79 | 10.20.2 | Část 2 | 9w | 2025-09-18 | 2025-11-19 | 68FF | 2d |  |  |
| 80 | 11 | **SO 02 Skluz - krytá část** | 1055d | 2021-10-11 | 2025-10-24 |  | 20d |  |  |
| 81 | 11.1 | **Zemní práce** | 935d | 2021-10-11 | 2025-05-09 |  | 140d |  |  |
| 82 | 11.1.1 | Zemní práce - část 1 | 1w | 2021-10-11 | 2021-10-15 |  | 310d | 0d | start no earlier than 2021-10-11 |
| 83 | 11.1.2 | Zemní práce - část 2 | 9w | 2023-04-03 | 2023-06-02 | 66FS-1w, 88SS, 90, 207 | 0d |  |  |
| 84 | 11.1.3 | Zemní práce - část 3 | 4w | 2023-07-03 | 2023-07-28 | 91SS+10w | 0d |  |  |
| 85 | 11.1.4 | Zemní práce - část 4 | 3w | 2024-06-17 | 2024-07-05 | 97SS+9w | 185d | 0d |  |
| 86 | 11.1.5 | Zemní práce - část 5 | 3w | 2025-01-06 | 2025-01-24 | 105 | 0d |  |  |
| 87 | 11.1.6 | Zemní práce - část 6 | 2w | 2025-04-28 | 2025-05-09 | 115FS-2w | 140d |  |  |
| 88 | 11.2 | Odstranění přemostění, části bloku 33P, schodiště, opěrných zdí | 4w | 2023-04-03 | 2023-04-28 | 14 | 0d |  |  |

| ID | WBS | Task | Duration | Start | Finish | Predecessors | Total slack | Free slack |
| --- | --- | --- | --- | --- | --- | --- | --- | --- |
| 89 | 11.3 | **Zakládání - zajištění stavební jámy (piloty, kotvy, sítě, svorníky)** | 720d | 2021-10-18 | 2024-07-19 |  | 185d |  |
| 90 | 11.3.1 | Zakládání - část 1 | 14w | 2021-10-18 | 2022-01-21 | 82 | 310d |  |
| 91 | 11.3.2 | Zakládání - část 2 | 10w | 2023-04-24 | 2023-06-30 | 83SS+3w | 0d |  |
| 92 | 11.3.3 | Zakládání - část 3 | 6w | 2023-07-10 | 2023-08-18 | 84SS+1w | 0d |  |
| 93 | 11.3.4 | Zakládání - část 4 | 4w | 2024-06-24 | 2024-07-19 | 85SS+1w | 185d | 0d |
| 94 | 11.4 | Vztlaková drenáž | 5w | 2023-08-21 | 2023-09-22 | 92 | 0d |  |
| 95 | 11.5 | **Betonáž dna** | 215d | 2023-09-04 | 2024-06-28 |  | 0d |  |
| 96 | 11.5.1 | Betonáž dna - část 1 | 13w | 2023-09-04 | 2023-12-01 | 94SS+2w | 0d |  |
| 97 | 11.5.2 | Betonáž dna - část 2 | 11w | 2024-04-15 | 2024-06-28 | 118 | 0d |  |
| 98 | 11.6 | Injektáž | 6w | 2023-09-11 | 2023-10-20 | 96SS+1w | 45d | 0d |
| 99 | 11.7 | Vlepování výztuže v místech injektáže | 2w | 2023-10-16 | 2023-10-27 | 98FS-1w | 45d |  |
| 100 | 11.8 | **Betonáž stěn vč. drenážních šachet a žeber** | 265d | 2024-01-01 | 2025-01-03 |  | 0d |  |
| 101 | 11.8.1 | Betonáž stěn - část 1 | 12w | 2024-01-01 | 2024-03-22 | 99, 96FS+4w | 0d |  |
| 102 | 11.8.2 | Betonáž stěn - část 2 | 7w | 2024-05-13 | 2024-06-28 | 97SS+4w | 0d |  |
| 103 | 11.8.3 | Betonáž stěn - část 3 | 4w | 2024-08-19 | 2024-09-13 | 125FS+4w | 0d |  |
| 104 | 11.8.4 | Betonáž stěn - část 4 | 4w | 2024-10-14 | 2024-11-08 | 103FS+4w | 0d |  |
| 105 | 11.8.5 | Betonáž stěn - část 5 | 4w | 2024-12-09 | 2025-01-03 | 104FS+4w | 0d |  |
| 106 | 11.9 | **Drenáž za rubem zdi** | 165d | 2024-05-20 | 2025-01-03 |  | 230d |  |
| 107 | 11.9.1 | Drenáž - část 1 | 30w | 2024-05-20 | 2024-12-13 | 113SS+4w | 245d |  |
| 108 | 11.9.2 | Drenáž - část 2 | 4w | 2024-12-09 | 2025-01-03 | 105SS | 230d |  |
| 109 | 11.10 | **Gabionové stěny** | 90d | 2025-01-20 | 2025-05-23 |  | 0d |  |
| 110 | 11.10.1 | Gabion 1 | 7w | 2025-01-20 | 2025-03-07 | 86FS-1w | 0d |  |
| 111 | 11.10.2 | Gabion 2 | 2w | 2025-05-12 | 2025-05-23 | 115 | 0d |  |
| 112 | 11.11 | **Zpětný zásyp** | 300d | 2024-04-22 | 2025-06-13 |  | 115d |  |
| 113 | 11.11.1 | Zásypy část 1 | 34w | 2024-04-22 | 2024-12-13 | 101FS+4w, 124 | 245d | 0d |
| 114 | 11.11.2 | Zásypy část 2 | 9w | 2024-12-09 | 2025-02-07 | 104FS+4w | 205d |  |
| 115 | 11.11.3 | Zásypy část 3 | 9w | 2025-03-10 | 2025-05-09 | 110, 129 | 0d |  |
| 116 | 11.11.4 | Zásypy část 4 | 3w | 2025-05-26 | 2025-06-13 | 111 | 0d |  |

| ID | WBS | Task | Duration | Start | Finish | Predecessors | Total slack | Free slack |
| --- | --- | --- | --- | --- | --- | --- | --- | --- |
| 117 | 11.12 | **Betonáž stropů** | 210d | 2024-03-25 | 2025-01-10 |  | 0d |  |
| 118 | 11.12.1 | Betonáž stropy - část 1 | 3w | 2024-03-25 | 2024-04-12 | 101 | 0d |  |
| 119 | 11.12.2 | Betonáž stropy - část 2 | 2w | 2024-07-01 | 2024-07-12 | 102 | 0d |  |
| 120 | 11.12.3 | Betonáž stropy - část 3 | 1w | 2024-09-16 | 2024-09-20 | 103 | 145d | 0d |
| 121 | 11.12.4 | Betonáž stropy - část 4 | 1w | 2024-11-11 | 2024-11-15 | 104 | 260d | 0d |
| 122 | 11.12.5 | Betonáž stropy - část 5 | 1w | 2025-01-06 | 2025-01-10 | 105 | 5d | 0d |
| 123 | 11.13 | **Betonáž mostních pilířů, opěrných stěn, atik** | 200d | 2024-04-15 | 2025-01-17 |  | 65d |  |
| 124 | 11.13.1 | Betonáž - část 1 | 1w | 2024-04-15 | 2024-04-19 | 118 | 245d | 0d |
| 125 | 11.13.2 | Betonáž - část 2 | 1w | 2024-07-15 | 2024-07-19 | 119 | 0d |  |
| 126 | 11.13.3 | Betonáž - část 3 | 1w | 2024-09-23 | 2024-09-27 | 120 | 300d |  |
| 127 | 11.13.4 | Betonáž - část 4 | 1w | 2024-11-18 | 2024-11-22 | 121 | 260d |  |
| 128 | 11.13.5 | Betonáž - část 5 | 1w | 2025-01-13 | 2025-01-17 | 122 | 160d | 158d |
| 129 | 11.14 | Drenáž nad stropy, dešťová kanalizace | 6w | 2025-01-20 | 2025-02-28 | 122FS+1w | 5d |  |
| 130 | 11.15 | Zpevněná plocha, základy pod mobilní hrazení, jeřábová dráha | 2w | 2025-05-12 | 2025-05-23 | 176FS+2w, 115 | 15d | 0d |
| 131 | 11.16 | Zpevněná plocha - část 2 | 5w | 2025-09-22 | 2025-10-24 | 57FS+1w, 72 | 0d |  |
| 132 | 11.17 | Skleněné stěny, sekční vrata, ventilace (vč. vnitřních rozvodů) | 2w | 2025-06-02 | 2025-06-13 | 130FS+1w | 115d |  |
| 133 | 11.18 | Oplocení, vjezdová brána (vč. přemístění založního zdroje - SO13) | 2w | 2025-05-26 | 2025-06-06 | 130 | 100d | 0d |
| 134 | 11.19 | Dokončovací práce (povrchové odvodnění, osetí, zábradlí, schodiště... | 5w | 2025-06-02 | 2025-07-04 | 133FS-1w | 100d |  |
| 135 | 12 | **SO 03 Skluz - otevřená část** | 1057d | 2021-02-18 | 2025-03-07 |  | 148d |  |
| 136 | 12.1 | Zemní práce, zakládání a zajištění stavební jámy | 22w | 2021-02-18 | 2021-07-21 | 10SS-1mo, 16 | 148d | 0d |
| 137 | 12.2 | **Podkladní betony** | 872d | 2021-03-25 | 2024-07-26 |  | 148d |  |
| 138 | 12.2.1 | Podkladní betony 1 | 4w | 2021-03-25 | 2021-04-21 | 136SS+5w | 148d | 0d |
| 139 | 12.2.2 | Podkladní betony 2 | 2w | 2021-05-13 | 2021-05-26 | 138FS+3w | 1172d |  |
| 140 | 12.2.3 | Podkladní betony 3 | 40w | 2021-06-17 | 2022-03-23 | 136FS-5w | 667d | 31d |
| 141 | 12.2.4 | Podladní betony 4 | 1w | 2024-07-22 | 2024-07-26 | 93 | 345d |  |
| 142 | 12.3 | Drenáž pode dnem skluzu | 2w | 2021-07-08 | 2021-07-21 | 136FF | 1132d |  |

| ID | WBS | Task | Duration | Start | Finish | Predecessors | Total slack | Free slack |
| --- | --- | --- | --- | --- | --- | --- | --- | --- |
| 143 | 12.4 | **Betonáž** | 811d | 2021-10-22 | 2024-11-29 | 27, 28, 29, 30 | 205d |  |
| 144 | 12.4.1 | Betonáž 1 | 75w | 2021-10-22 | 2023-04-06 | 47, 140SS+12w, 27, 28, 29, 30 | 636d | 0d |
| 145 | 12.4.2 | Betonáž 2 | 19w | 2024-07-22 | 2024-11-29 | 93 | 185d | 0d |
| 146 | 12.5 | **Drenážní systém za rubem zdí** | 526d | 2022-11-25 | 2024-11-29 |  | 255d |  |
| 147 | 12.5.1 | Drenáž část 1 | 4w | 2022-11-25 | 2022-12-22 | 144SS+57w | 761d |  |
| 148 | 12.5.2 | Drenáž část 2 | 3w | 2024-11-11 | 2024-11-29 | 145FF | 185d | 0d |
| 149 | 12.6 | **Zpětné zásypy** | 511d | 2023-02-03 | 2025-01-17 |  | 185d |  |
| 150 | 12.6.1 | Zpětné zásypy 1 | 8w | 2023-02-03 | 2023-03-30 | 144FS-9w | 636d | 0d |
| 151 | 12.6.2 | Zpětné zásypy 2 | 7w | 2024-12-02 | 2025-01-17 | 148 | 185d | 0d |
| 152 | 12.7 | **Schodiště** | 486d | 2023-03-31 | 2025-02-07 |  | 205d |  |
| 153 | 12.7.1 | Část 1 dolní | 6w | 2023-03-31 | 2023-05-11 | 150 | 661d |  |
| 154 | 12.7.2 | Část 2 horní | 5w | 2025-01-06 | 2025-02-07 | 151FS-2w | 185d | 0d |
| 155 | 12.8 | Betonáž opěrných zdí | 6w | 2022-11-04 | 2022-12-15 | 144SS+54w | 701d | 50d |
| 156 | 12.9 | Příjezdová komunikace k dolní stanici výtahu | 5w | 2023-03-24 | 2023-04-27 | 155FS+4w, 150FS-1w | 651d | 0d |
| 157 | 12.10 | **Povrchové odvodnění** | 471d | 2023-04-28 | 2025-02-14 |  | 200d |  |
| 158 | 12.10.1 | Odvodnění dolní | 4w | 2023-04-28 | 2023-05-25 | 156 | 651d |  |
| 159 | 12.10.2 | Odvodnění horní | 2w | 2025-02-03 | 2025-02-14 | 154FS-1w | 185d | 0d |
| 160 | 12.11 | Dokončovací práce | 4w | 2025-02-10 | 2025-03-07 | 159FS-1w | 185d |  |
| 161 | 13 | **SO 04 Opevnění dna** | 77d | 2023-08-15 | 2023-11-30 |  | 517d |  |
| 162 | 13.1 | Odstranění zbytků stávajícího opevnění | 3w | 2023-08-15 | 2023-09-04 | 12, 150 | 539d | 0d |
| 163 | 13.2 | Tvarové úpravy dna | 3w | 2023-08-15 | 2023-09-04 | 162SS | 539d | 22d |
| 164 | 13.3 | Položení kamenné dlažby a záhozové patky | 9w | 2023-09-28 | 2023-11-30 | 163SS+2w, 13FF | 517d |  |
| 165 | 14 | **SO 05 Rekonstrukce přemostění hráze** | 60d | 2024-08-12 | 2024-11-01 |  | 15d | 0d |
| 166 | 14.1 | Osazení ložisek | 1w | 2024-08-12 | 2024-08-16 | 125FS+3w | 15d | 0d |
| 167 | 14.2 | Osazení prefabrikátů | 1w | 2024-08-19 | 2024-08-23 | 166 | 15d | 0d |
| 168 | 14.3 | Armování desek | 2w | 2024-08-26 | 2024-09-06 | 167 | 15d | 0d |
| 169 | 14.4 | Betonáž desek | 1w | 2024-09-09 | 2024-09-13 | 168 | 15d | 0d |
| 170 | 14.5 | Provedení přechodové oblasti | 1w | 2024-09-02 | 2024-09-09 | 169SF | 285d |  |
| 171 | 14.6 | Izolace mostovky | 1w | 2024-10-07 | 2024-10-11 | 169FS+3w | 15d | 0d |
| 172 | 14.7 | Betonáž říms | 1w | 2024-10-14 | 2024-10-18 | 171 | 15d | 0d |
| 173 | 14.8 | Betonáž zábradlí | 1w | 2024-10-21 | 2024-10-25 | 172 | 15d | 0d |
| 174 | 14.9 | Provedení vozovky | 1w | 2024-10-28 | 2024-11-01 | 173 | 15d | 10d |

| ID | WBS | Task | Duration | Start | Finish | Predecessors | Total slack | Free slack | Constraint |
| --- | --- | --- | --- | --- | --- | --- | --- | --- | --- |
| 175 | 15 | **SO 06 Rekonstrukce mobilního hrazení** | 305d | 2024-09-23 | 2025-11-21 |  | 0d |  |  |
| 176 | 15.1 | Základový pás pro osazení mobilního hrazení | 5w | 2024-09-23 | 2024-10-25 | 120 | 145d | 130d |  |
| 177 | 15.2 | Dokončovací práce | 3w | 2025-11-03 | 2025-11-21 | 176, 131FS+1w | 0d |  |  |
| 178 | 16 | **SO 07 Rekonstrukce příjezdové komunikace** | 610d | 2023-03-20 | 2025-07-18 |  | 0d |  |  |
| 179 | 16.1 | Odstranění stávajících povrchů - beton, vozovka | 2w | 2023-03-20 | 2023-03-31 | 66FS-1w | 580d |  |  |
| 180 | 16.2 | Úprava zemní pláně | 1w | 2025-06-23 | 2025-06-27 | 179, 200SS+1w | 0d |  |  |
| 181 | 16.3 | Provedení komunikace (drenáž, geotextílie, podklad, vozovka) | 3w | 2025-06-30 | 2025-07-18 | 180, 130FS+2w | 0d |  |  |
| 182 | 17 | **SO 08 Demolice garáží** | 10d | 2020-12-30 | 2021-01-12 | 3 | 234d | 185d |  |
| 183 | 17.1 | Demolice | 2w | 2020-12-30 | 2021-01-12 | 202SS, 209SS, 3 | 234d | 224d |  |
| 184 | 18 | **SO 09 Přípojka NN** | 45d | 2025-06-23 | 2025-08-22 |  | 65d |  |  |
| 185 | 18.1 | Definitivní přípojka | 9w | 2025-06-23 | 2025-08-22 | 130FS+4w | 65d |  |  |
| 186 | 19 | **SO 10 Přípojka sdělovacích kabelů** | 45d | 2025-06-23 | 2025-08-22 |  | 65d |  |  |
| 187 | 19.1 | Definitivní přípojka | 9w | 2025-06-23 | 2025-08-22 | 130FS+4w | 65d |  |  |
| 188 | 20 | **SO 11 Vegetační úpravy** | 1253d | 2020-12-30 | 2025-10-17 |  | 25d |  |  |
| 189 | 20.1 | Kácení | 9w | 2020-12-30 | 2021-03-02 | 3 | 1233d |  |  |
| 190 | 20.2 | Náhradní výsadba | 7w | 2025-09-01 | 2025-10-17 | 116, 151 | 25d |  | start no earlier than 2025-09-01 |
| 191 | 21 | **SO 13 Přeložka záložního zdroje** | 978d | 2021-10-06 | 2025-07-04 |  | 100d |  |  |
| 192 | 21.1 | Dočasná přeložka | 3w | 2021-10-06 | 2021-10-26 | 3, 82SS-3d | 1063d |  |  |
| 193 | 21.2 | Definitivní přeložka | 2w | 2025-06-23 | 2025-07-04 | 130FS+4w | 100d |  |  |
| 194 | 22 | **SO 14 Přeložka veřejného osvětlení** | 1005d | 2021-09-20 | 2025-07-25 |  | 85d |  |  |
| 195 | 22.1 | Demotnáž VO | 3w | 2021-09-20 | 2021-10-08 | 3, 82SS-3w | 1075d |  |  |
| 196 | 22.2 | Definitivní přeložka VO | 6w | 2025-06-16 | 2025-07-25 | 116, 165 | 85d |  |  |
| 197 | 23 | **SO 15 Přeložka splaškové kanalizace** | 978d | 2021-10-27 | 2025-07-25 |  | 85d |  |  |
| 198 | 23.1 | Dočasná přeložka - I.etapa | 3w | 2021-10-27 | 2021-11-16 | 49SS+8w | 1048d |  |  |
| 199 | 23.2 | Dočasná přeložka - II. Etapa | 1w | 2022-12-20 | 2022-12-26 | 56FS+2w | 54d | 44d |  |
| 200 | 23.3 | Definitivní přeložka | 6w | 2025-06-16 | 2025-07-25 | 116 | 0d |  |  |

Notes:
- 189: Možný termín 1.11.2019 až 31.3.2020 dle rozhodnutí OÚ Milešov
- 190: Provést ve vhodném období, tj. podzim/jaro.

| ID | WBS | Task | Type | Duration | Start | Finish | Predecessors | Total slack | Free slack |
| --- | --- | --- | --- | --- | --- | --- | --- | --- | --- |
| 201 | 24 | **SO 16 Přeložka NN** |  | 1023d | 2020-12-30 | 2024-11-29 | 3 | 234d |  |
| 202 | 24.1 | Dočasná přeložka 1.etapa |  | 3w | 2020-12-30 | 2021-01-19 | 3 | 234d | 0d |
| 203 | 24.2 | Dočasná přeložka 2.etapa |  | 1w | 2022-12-20 | 2022-12-26 | 56FS+2w | 54d | 44d |
| 204 | 24.3 | Definitivní přeložka NN pro provozní budovu |  | 4w | 2024-11-04 | 2024-11-29 | 165 | 255d |  |
| 205 | 25 | **SO 17 Přeložka vodovodní přípojky** |  | 383d | 2021-09-29 | 2023-03-17 |  | 383d |  |
| 206 | 25.1 | Dočasná přeložka |  | 3w | 2021-09-29 | 2021-10-19 | 49SS+4w, 182 | 1068d |  |
| 207 | 25.2 | Definitivní přeložka |  | 2w | 2023-03-06 | 2023-03-17 | 70 | 10d |  |
| 208 | 26 | **SO 18 Přeložka sdělovacího vedení** |  | 1023d | 2020-12-30 | 2024-11-29 | 3 | 234d |  |
| 209 | 26.1 | Dočasná přeložka 1.etapa |  | 3w | 2020-12-30 | 2021-01-19 | 3 | 234d | 0d |
| 210 | 26.2 | Dočasná přeložka 2.etapa |  | 1w | 2022-12-20 | 2022-12-26 | 56FS+2w | 54d | 44d |
| 211 | 26.3 | Definitivní přeložka sdělovacích vedení |  | 4w | 2024-11-04 | 2024-11-29 | 165 | 255d |  |
| 212 | 27 | Dokončení stavebních prací na díle - technická přejímka | milestone | 0d | 2025-11-21 | 2025-11-21 | 48, 80, 135, 161, 165, 175, 178, 182, 184, 186, 188, 191, 194, 197, 201, 205, 208 | 0d |  |
| 213 | 28 | Dokončení díla | milestone | 0d | 2025-12-19 | 2025-12-19 | 212FS+1mo | 0d |  |
